# PAQUETE 09 RIO CHICAMA TRAMO

Schedule from Primavera P6, 2024-12-02 to 2026-05-29, data date 2024-12-02.
Must finish by 2026-05-29

## Calendars

- 1T - 7x0 - 8 hr: Mon-Sun 08:00-16:00.

## Resources

| Resource | Group |
| --- | --- |
| Excavadora Cat 336 | equipment |
| TRACTOR SOBRE ORUGAS CAT D8T | equipment |
| TRACTOR SOBRE ORUGAS CAT D6D | equipment |

## Schedule

| ID | WBS | Activity | Type | Duration | Start | Finish | Predecessors | Total float | Free float |
| --- | --- | --- | --- | --- | --- | --- | --- | --- | --- |
|  | 0 | **HITOS** |  |  | 2024-12-02 | 2026-05-29 |  |  |  |
| A1000 |  | Inicio de obra - Acceso al Sitio | milestone | 0d | 2024-12-02 | 2024-12-02 |  | 0d |  |
| A1010 |  | Culminación de obras | milestone | 0d | 2026-05-29 | 2026-05-29 | A1250, A3690, A1030 FF, A1160 FF, A1210 FF, A1240 FF, A1260 FF, A1290 FF, A1290 SF, A1060 FF, A5930 FF, A5940 FF, A5950 FF, A5960 FF, A5970 FF, A5900 FF, A5920 FF, A3700 FF, A1330 FF | 0d |  |
|  | 1 | **OBRAS PRELIMINARES** |  |  | 2024-12-02 | 2026-05-29 |  |  |  |
|  | 1 | **MOVILIZACIÓN Y DESMOVILIZACIÓN** |  |  | 2024-12-02 | 2026-05-29 |  |  |  |
| A1020 |  | Movilización de equipos a obra |  | 25d | 2024-12-02 | 2024-12-26 | A1000 | 0d |  |
| A1030 |  | Desmovilización de equipos a obra |  | 20d | 2026-05-10 | 2026-05-29 | A5880 | 0d |  |
|  | 2 | **TRAZO Y REPLANTEO** |  |  | 2024-12-05 | 2026-04-12 |  |  |  |
| A1040 |  | Trazo y replanteo topográfico al inicio de obra |  | 15d | 2024-12-05 | 2024-12-19 | A1020 SS+3d | 0d |  |
| A1050 |  | Trazo y replanteo topográfico durante la ejecución de obra |  | 465d | 2024-12-19 | 2026-03-28 | A1000 SS+17d | 1d | 0d |
| A1060 |  | Levantamiento topografico final de obra |  | 15d | 2026-03-29 | 2026-04-12 | A1050 | 47d |  |
|  | 3 | **ACCESOS** |  |  | 2024-12-20 | 2026-04-18 |  |  |  |
|  | 2 | **REHABILITACIÓN DE ACCESOS EXISTENTES** |  |  | 2024-12-20 | 2024-12-29 |  |  |  |
| A1130 |  | Rehabilitación de accesos existentes |  | 10d | 2024-12-20 | 2024-12-29 | A1050 SS, A1020 SS+1d, A1040 | 0d |  |
|  | 3 | **MANTENIMIENTO DE ACCESOS** |  |  | 2025-01-04 | 2026-04-18 |  |  |  |
| A1160 |  | Mantenimiento de accesos (L<15 km) |  | 470d | 2025-01-04 | 2026-04-18 | A1130 SS+15d, A1020 | 41d |  |
|  | 1 | **CONSTRUCCIÓN DE ACCESO NUEVO** |  |  | 2025-01-02 | 2025-02-13 |  |  |  |
| A1070 |  | Desbroce y remoción de suelo vegetal con equipo |  | 6d | 2025-01-02 | 2025-01-07 | A1130 SS+13d | 20d | 0d |
| A1080 |  | Excavación en material común para accesos |  | 13d | 2025-01-02 | 2025-01-14 | A1070 SS | 20d | 0d |
| A1110 |  | Relleno compactado con equipo pesado para accesos |  | 30d | 2025-01-15 | 2025-02-13 | A1080 | 20d | 0d |
|  | 4 | **ACCESO EN CAUCE DE RÍO** |  |  | 2024-12-30 | 2025-01-28 |  |  |  |
| A1170 |  | Habilitación de acceso temporal en cauce de río. (Inc. Colocación y Retiro de alcantarilla) |  | 30d | 2024-12-30 | 2025-01-28 | A1130 SS+10d | 0d |  |
|  | 4 | **CAMPAMENTOS** |  |  | 2024-12-20 | 2026-05-09 |  |  |  |
|  | 1 | **CONSTRUCCIÓN DE CAMPAMENTOS (TALLERES, ALMACENES Y OFICINAS)** |  |  | 2024-12-20 | 2025-02-09 |  |  |  |
| A1180 |  | Desbroce y remoción de suelo vegetal con equipo |  | 2d | 2024-12-20 | 2024-12-21 | A1040 | 3d | 0d |
| A1190 |  | Conformación de terraplén para campamentos |  | 8d | 2024-12-22 | 2024-12-29 | A1180 | 3d | 0d |
| A1200 |  | Construcción de campamentos |  | 35d | 2025-01-06 | 2025-02-09 | A1190 SS+15d, A1230 | 3d | 0d |

| ID | WBS | Activity | Duration | Start | Finish | Predecessors | Total float | Free float |
| --- | --- | --- | --- | --- | --- | --- | --- | --- |
|  | 2 | **MANTENIMIENTO DE CAMPAMENTOS** |  | 2025-02-14 | 2026-05-09 |  |  |  |
| A1210 |  | Mantenimiento de campamentos | 450d | 2025-02-14 | 2026-05-09 | A1200 SS+30d, A1110 | 20d |  |
|  | 5 | **DESVÍO TEMPORAL DEL RÍO** |  | 2025-01-09 | 2026-05-05 |  |  |  |
|  | 1 | **SECTOR 1** |  | 2025-01-09 | 2025-04-23 |  |  |  |
| A1220 |  | Conformación de ataguía para desvio temporal del cause del rio | 105d | 2025-01-09 | 2025-04-23 | A1170 SS+10d, A1190 | 0d |  |
| A1320 |  | Conformación de ataguía con revestimiento, con bolsa de geotextil tejido de alta resistencia para desvio temporal de rio | 105d | 2025-01-09 | 2025-04-23 | A1170 SS+10d, A1190 | 0d |  |
|  | 2 | **SECTOR 2** |  | 2025-03-17 | 2025-05-15 |  |  |  |
| A5980 |  | Conformación de ataguía para desvio temporal del cause del rio | 60d | 2025-03-17 | 2025-05-15 | A1200 FS+35d | 3d | 0d |
| A5990 |  | Conformación de ataguía con revestimiento, con bolsa de geotextil tejido de alta resistencia para desvio temporal de rio | 55d | 2025-03-22 | 2025-05-15 | A5980 SS+5d | 35d | 29d |
|  | 3 | **SECTOR 3** |  | 2025-05-16 | 2026-03-21 |  |  |  |
| A6000 |  | Conformación de ataguía para desvio temporal del cause del rio | 310d | 2025-05-16 | 2026-03-21 | A5980 | 3d | 0d |
| A6010 |  | Conformación de ataguía con revestimiento, con bolsa de geotextil tejido de alta resistencia para desvio temporal de rio | 308d | 2025-05-18 | 2026-03-21 | A6000 SS+2d | 9d | 3d |
|  | 4 | **SECTOR 4** |  | 2026-01-01 | 2026-03-26 |  |  |  |
| A6020 |  | Conformación de ataguía para desvio temporal del cause del rio | 80d | 2026-01-01 | 2026-03-21 | A6000 SS+230d | 3d | 0d |
| A6030 |  | Conformación de ataguía con revestimiento, con bolsa de geotextil tejido de alta resistencia para desvio temporal de rio | 80d | 2026-01-06 | 2026-03-26 | A6020 SS+5d | 3d | 0d |
|  | 5 | **SECTOR 5** |  | 2026-02-05 | 2026-05-05 |  |  |  |
| A6040 |  | Conformación de ataguía para desvio temporal del cause del rio | 85d | 2026-02-05 | 2026-04-30 | A6020 SS+35d | 6d | 0d |
| A6050 |  | Conformación de ataguía con revestimiento, con bolsa de geotextil tejido de alta resistencia para desvio temporal de rio | 85d | 2026-02-10 | 2026-05-05 | A6040 SS+5d | 6d | 3d |
|  | 6 | **CONTROLES AMBIENTALES Y SEÑALIZACIÓN** |  | 2024-12-05 | 2026-05-08 |  |  |  |
|  | 1 | **SEÑALIZACIÓN** |  | 2024-12-05 | 2026-04-13 |  |  |  |
| A1240 |  | Señalización de obra | 495d | 2024-12-05 | 2026-04-13 | A1040 SS | 46d |  |
| A1230 |  | Cartel de Obra de 7.00 x 3.50 m | 5d | 2024-12-20 | 2024-12-24 | A1040 | 15d | 12d |
|  | 2 | **CONTROLES AMBIENTALES** |  | 2024-12-05 | 2026-04-14 |  |  |  |
| A1250 |  | Implementación de controles ambientales durante la construcción | 480d | 2024-12-05 | 2026-03-29 | A1040 SS | 45d | 0d |
| A1260 |  | Restauración y revegetación de áreas intervenidas | 16d | 2026-03-30 | 2026-04-14 | A1250 | 45d |  |

| ID | WBS | Activity | Duration | Start | Finish | Predecessors | Total float | Free float | Resources |
| --- | --- | --- | --- | --- | --- | --- | --- | --- | --- |
|  | 3 | **DME Y DMO** |  | 2024-12-15 | 2026-05-08 |  |  |  |  |
| A1300 |  | Desbroce y remoción de suelo vegetal con equipo | 52d | 2024-12-15 | 2025-02-04 | A1020 SS+13d | 26d | 5d |  |
| A1270 |  | Acondicionamiento de terrenos para DME y DMO | 96d | 2024-12-20 | 2025-03-25 | A1040, A1300 SS | 21d | 0d |  |
| A1280 |  | Conformación de material excedente en DME y DMO | 475d | 2025-01-04 | 2026-04-23 | A1270 SS+15d | 21d | 0d |  |
| A1330 |  | Restauración y revegetación de áreas intervenidas | 15d | 2026-04-24 | 2026-05-08 | A1280 | 21d |  |  |
|  | 7 | **PRODUCCIÓN DE MATERIAL** |  | 2024-12-09 | 2026-04-12 |  |  |  |  |
| A1310 |  | Movilización, montaje y habilitación plantas de procesamiento | 50d | 2024-12-09 | 2025-01-27 | A1020 SS+7d, A1000 SS | 47d | 0d |  |
| A1290 |  | Proceso y selección de material propio | 440d | 2025-01-28 | 2026-04-12 | A1020 SS+15d, A1310, A4580 SS+2d | 47d |  |  |
|  | 4 | **TRANSPORTES** |  | 2025-01-04 | 2026-04-25 |  |  |  |  |
| A5940 |  | Transporte de material excedente a DME, DMO | 465d | 2025-01-04 | 2026-04-13 | A1280 SS | 46d |  |  |
| A5970 |  | Transporte de matrial comun saturado excedente a DME | 465d | 2025-01-04 | 2026-04-13 | A1280 SS | 46d |  |  |
| A5930 |  | Transporte de material propio para relleno | 420d | 2025-02-15 | 2026-04-10 | A4610, A4810 | 49d |  |  |
| A5950 |  | Transporte de roca seleccionada de cantera para enrocado de proteccion | 405d | 2025-03-17 | 2026-04-25 | A4530 SS, A4760 SS | 34d |  |  |
| A5960 |  | Transporte de roca rechazada a DMO | 405d | 2025-03-17 | 2026-04-25 | A4760 SS, A4530 SS | 34d |  |  |
|  | 20 | **ENCAUZAMIENTO DE RÍO CHICAMA** |  | 2025-01-11 | 2026-05-09 |  |  |  |  |
|  | 1 | **SECTOR1** |  | 2025-01-11 | 2025-05-09 |  |  |  |  |
|  | 3 | **S1-DIPR-02MI - MARGEN IZQUIERO** |  | 2025-01-19 | 2025-05-09 |  |  |  |  |
|  | 2 | **REMOCION DE ENROCADO DE DIQUES EN MAL ESTADO-1** |  | 2025-01-19 | 2025-02-06 |  |  |  |  |
| A4730 |  | Remoción de enrocado de cara húmeda de talud | 19d | 2025-01-19 | 2025-02-06 | A4740 SS | 6d | 0d |  |
| A4740 |  | Selección y acopio de roca removida | 9d | 2025-01-19 | 2025-01-27 | A1170 SS+8d, A1220 SS+10d, A1320 SS+10d | 6d | 0d |  |
|  | 3 | **MOVIMIENTO DE TIERRAS PARA DIQUE LONGITUDINALES** |  | 2025-01-20 | 2025-04-12 |  |  |  |  |
|  | 1 | **EXCAVACIÓN** |  | 2025-01-20 | 2025-03-13 |  |  |  |  |
| A4570 |  | Desbroce y remoción de suelo vegetal con equipo | 10d | 2025-01-20 | 2025-01-29 | A4730 SS+1d | 6d | 0d | Excavadora Cat 336 [64 h]; TRACTOR SOBRE ORUGAS CAT D8T [80 h] |
| A4580 |  | Excavación en material común | 50d | 2025-01-21 | 2025-03-11 | A4570 SS+1d | 6d | 0d | TRACTOR SOBRE ORUGAS CAT D6D [400 h]; Excavadora Cat 336 [400 h] |
| A4590 |  | Excavación para conformación de uña antisocavante | 42d | 2025-01-31 | 2025-03-13 | A4580 SS+10d | 23d | 0d |  |

| ID | WBS | Activity | Duration | Start | Finish | Predecessors | Total float | Free float |
| --- | --- | --- | --- | --- | --- | --- | --- | --- |
|  | 2 | **RELLENO** |  | 2025-02-05 | 2025-04-12 |  |  |  |
| A4610 |  | Conformación y compactación de superficie para fundación con equipo pesado | 7d | 2025-02-05 | 2025-02-11 | A4580 SS+15d | 6d | 0d |
| A4620 |  | Relleno compactado con equipo pesado | 32d | 2025-02-13 | 2025-03-16 | A4610 SS+8d | 6d | 0d |
| A4640 |  | Perfilado de taludes de dique con equipo | 32d | 2025-02-21 | 2025-03-24 | A4620 SS+8d | 6d | 0d |
| A4650 |  | Suministro, habilitación y colocación de geotextil no tejido 400 g/m2 | 24d | 2025-02-21 | 2025-03-16 | A4640 SS | 6d | 0d |
| A4630 |  | Relleno propio sin compactar | 30d | 2025-03-14 | 2025-04-12 | A4540 SS | 46d | 26d |
|  | 1 | **SISTEMA DE CONFINAMIENTO CON GEOCELDAS-1** |  | 2025-03-13 | 2025-03-16 |  |  |  |
| A4680 |  | Suministro, habilitación y colocación de geotextil no tejido 200 g/m2 | 4d | 2025-03-13 | 2025-03-16 | A4650 FF | 6d | 0d |
|  | 7 | **ENROCADO DE PROTECCIÓN** |  | 2025-03-14 | 2025-05-09 |  |  |  |
| A4540 |  | Colocación de roca seleccionada, en uña antisocavante | 57d | 2025-03-14 | 2025-05-09 | A4590 | 23d | 0d |
| A4530 |  | Colocación de roca seleccionada, en cara húmeda de talud | 34d | 2025-03-17 | 2025-04-19 | A4580, A4680 | 6d | 0d |
|  | 7 | **S1-DIPR-03MD - MARGEN DERECHO** |  | 2025-01-11 | 2025-04-08 |  |  |  |
|  | 3 | **MOVIMIENTO DE TIERRAS PARA DIQUE LONGITUDINALES** |  | 2025-01-11 | 2025-03-05 |  |  |  |
|  | 1 | **EXCAVACIÓN** |  | 2025-01-11 | 2025-02-16 |  |  |  |
| A4770 |  | Desbroce y remoción de suelo vegetal con equipo | 10d | 2025-01-11 | 2025-01-20 | A1170 SS+4d, A1220 SS+2d, A1320 SS+2d | 0d |  |
| A4780 |  | Excavación en material común | 14d | 2025-01-12 | 2025-01-25 | A4770 SS+1d | 0d |  |
| A4790 |  | Excavación para conformación de uña antisocavante | 17d | 2025-01-31 | 2025-02-16 | A4780 FS+5d | 0d |  |
|  | 2 | **RELLENO** |  | 2025-01-26 | 2025-03-05 |  |  |  |
| A4800 |  | Excavación de zanja de anclaje para geotextil | 10d | 2025-01-26 | 2025-02-04 | A4780 | 44d | 17d |
| A4810 |  | Conformación y compactación de superficie para fundación con equipo pesado | 19d | 2025-01-27 | 2025-02-14 | A4780 SS+15d | 5d | 0d |
| A4820 |  | Relleno compactado con equipo pesado | 22d | 2025-02-04 | 2025-02-25 | A4810 SS+8d | 5d | 0d |
| A4840 |  | Perfilado de taludes de dique con equipo | 18d | 2025-02-12 | 2025-03-01 | A4820 SS+8d | 5d | 0d |
| A4830 |  | Relleno propio sin compactar | 12d | 2025-02-22 | 2025-03-05 | A4760 SS+5d | 13d |  |
| A4850 |  | Suministro, habilitación y colocación de geotextil no tejido 400 g/m2 | 1d | 2025-02-22 | 2025-02-22 | A4840 SS+10d, A4800 | 27d | 0d |

| ID | WBS | Activity | Duration | Start | Finish | Predecessors | Total float | Free float |
| --- | --- | --- | --- | --- | --- | --- | --- | --- |
|  | 1 | **SISTEMA DE CONFINAMIENTO CON GEOCELDAS-1** |  | 2025-03-04 | 2025-04-08 |  |  |  |
| A4860 |  | Suministro, habilitación y colocación de geotextil no tejido 200 g/m2 | 17d | 2025-03-04 | 2025-03-20 | A4850 SS+10d | 27d | 0d |
| A4880 |  | Suministro, habilitación y colocación de sistema de confinamiento geocelda h=100 mm | 28d | 2025-03-12 | 2025-04-08 | A4860 SS+8d | 27d | 0d |
| A4870 |  | Suministro y colocación de concreto premezclado f'c=210 kg/cm2 para geocelda | 22d | 2025-03-17 | 2025-04-07 | A4880 SS+5d | 27d |  |
|  | 7 | **ENROCADO DE PROTECCIÓN** |  | 2025-02-17 | 2025-03-20 |  |  |  |
| A4760 |  | Colocación de roca seleccionada, en uña antisocavante | 23d | 2025-02-17 | 2025-03-11 | A4790, A4840 SS | 0d |  |
| A4750 |  | Colocación de roca seleccionada, en cara húmeda de talud | 2d | 2025-03-19 | 2025-03-20 | A4760 FS+7d, A4830 | 0d |  |
|  | 3 | **SECTOR 2** |  | 2025-03-21 | 2025-05-29 |  |  |  |
|  | 6 | **S2-DIPR-02MI - MARGEN IZQUIERDO** |  | 2025-04-20 | 2025-05-29 |  |  |  |
|  | 1 | **MOVIMIENTO DE TIERRAS PARA DIQUE LONGITUDINALES** |  | 2025-04-20 | 2025-05-17 |  |  |  |
|  | 1 | **EXCAVACIÓN** |  | 2025-04-20 | 2025-05-17 |  |  |  |
| A4360 |  | Desbroce y remoción de suelo vegetal con equipo | 3d | 2025-04-20 | 2025-04-22 | A4530, A5990 SS | 6d | 0d |
| A4370 |  | Excavación en material común | 16d | 2025-04-23 | 2025-05-08 | A4360 | 6d | 0d |
| A4380 |  | Excavación para conformación de uña antisocavante | 9d | 2025-05-09 | 2025-05-17 | A4370 | 15d | 0d |
|  | 2 | **RELLENO** |  | 2025-04-26 | 2025-05-12 |  |  |  |
| A4400 |  | Conformación y compactación de superficie para fundación con equipo pesado | 5d | 2025-04-26 | 2025-04-30 | A4370 SS+3d, A4680 | 6d | 0d |
| A4410 |  | Relleno compactado con equipo pesado | 9d | 2025-04-29 | 2025-05-07 | A4400 SS+3d, A4620 | 6d | 0d |
| A4430 |  | Perfilado de taludes de dique con equipo | 7d | 2025-05-02 | 2025-05-08 | A4410 SS+3d | 6d | 0d |
| A4420 |  | Relleno propio sin compactar | 4d | 2025-05-09 | 2025-05-12 | A4370, A4630 | 20d | 5d |
|  | 3 | **ENROCADO DE PROTECCIÓN** |  | 2025-05-09 | 2025-05-29 |  |  |  |
| A2640 |  | Colocación de roca seleccionada, en cara húmeda de talud | 12d | 2025-05-09 | 2025-05-20 | A4370, A4430, A4630 SS | 6d | 0d |
| A2650 |  | Colocación de roca seleccionada, en uña antisocavante | 12d | 2025-05-18 | 2025-05-29 | A4380, A4540, A4630 SS, A4420 | 15d | 9d |
|  | 8 | **S2-DIPR-03MD - MARGEN DERECHO** |  | 2025-03-21 | 2025-05-17 |  |  |  |
|  | 1 | **MOVIMIENTO DE TIERRAS PARA DIQUE LONGITUDINALES** |  | 2025-03-21 | 2025-04-16 |  |  |  |
|  | 1 | **EXCAVACIÓN** |  | 2025-03-21 | 2025-04-08 |  |  |  |
| A4930 |  | Desbroce y remoción de suelo vegetal con equipo | 4d | 2025-03-21 | 2025-03-24 | A4750 | 0d |  |
| A4940 |  | Excavación en material común | 6d | 2025-03-25 | 2025-03-30 | A4930 | 0d |  |
| A4950 |  | Excavación para conformación de uña antisocavante | 9d | 2025-03-31 | 2025-04-08 | A4940 | 22d | 0d |

| ID | WBS | Activity | Duration | Start | Finish | Predecessors | Total float | Free float |
| --- | --- | --- | --- | --- | --- | --- | --- | --- |
|  | 2 | **RELLENO** |  | 2025-03-28 | 2025-04-16 |  |  |  |
| A4970 |  | Conformación y compactación de superficie para fundación con equipo pesado | 4d | 2025-03-28 | 2025-03-31 | A4940 SS+3d | 0d |  |
| A4960 |  | Excavación de zanja de anclaje para geotextil | 0d | 2025-03-31 | 2025-03-31 | A4940 | 23d |  |
| A4980 |  | Relleno compactado con equipo pesado | 11d | 2025-03-31 | 2025-04-10 | A4970 SS+3d | 0d |  |
| A5000 |  | Perfilado de taludes de dique con equipo | 14d | 2025-04-03 | 2025-04-16 | A4980 SS+3d | 0d |  |
| A5010 |  | Suministro, habilitación y colocación de geotextil no tejido 400 g/m2 | 6d | 2025-04-08 | 2025-04-13 | A5000 SS+5d | 0d |  |
| A4990 |  | Relleno propio sin compactar | 4d | 2025-04-09 | 2025-04-12 | A5010 SS, A4830, A4950 | 22d |  |
|  | 3 | **ENROCADO DE PROTECCIÓN** |  | 2025-04-23 | 2025-05-17 |  |  |  |
| A4920 |  | Colocación de roca seleccionada, en uña antisocavante | 12d | 2025-04-23 | 2025-05-04 | A5010 SS+15d, A4960 | 0d |  |
| A4910 |  | Colocación de roca seleccionada, en cara húmeda de talud | 13d | 2025-05-05 | 2025-05-17 | A4920, A4870, A4990 | 0d |  |
|  | 6 | **SECTOR 3** |  | 2025-05-18 | 2026-03-25 |  |  |  |
|  | 4 | **S3-DIPR-01MI - MARGEN IZQUIERDO** |  | 2025-05-21 | 2025-09-13 |  |  |  |
|  | 5 | **MOVIMIENTO DE TIERRAS PARA DIQUE LONGITUDINALES** |  | 2025-05-21 | 2025-08-24 |  |  |  |
|  | 1 | **EXCAVACIÓN** |  | 2025-05-21 | 2025-07-20 |  |  |  |
| A4180 |  | Desbroce y remoción de suelo vegetal con equipo | 27d | 2025-05-21 | 2025-06-16 | A2640, A6010 SS | 6d | 0d |
| A4670 |  | Excavación en material común saturado | 16d | 2025-05-23 | 2025-06-07 | A4180 SS+2d | 6d | 0d |
| A4190 |  | Excavación para conformación de uña antisocavante | 24d | 2025-06-08 | 2025-07-01 | A4670, A2650 | 6d | 0d |
| A4660 |  | Excavación en material común | 19d | 2025-07-02 | 2025-07-20 | A4190 | 8d | 0d |
|  | 2 | **RELLENO** |  | 2025-07-12 | 2025-08-24 |  |  |  |
| A4210 |  | Conformación y compactación de superficie para fundación con equipo pesado | 1d | 2025-07-12 | 2025-07-12 | A4660 SS+10d, A4430 | 8d | 0d |
| A4220 |  | Relleno compactado con equipo pesado | 25d | 2025-07-17 | 2025-08-10 | A4210 SS+5d, A4410 | 44d | 0d |
| A4240 |  | Perfilado de taludes de dique con equipo | 19d | 2025-07-17 | 2025-08-04 | A4210 SS+5d, A4430, A4420 SS | 8d | 0d |
| A4200 |  | Excavación de zanja de anclaje para geotextil | 4d | 2025-07-27 | 2025-07-30 | A4240 SS+10d | 8d | 0d |
| A4250 |  | Suministro, habilitación y colocación de geotextil no tejido 400 g/m2 | 11d | 2025-08-02 | 2025-08-12 | A4200 SS+6d | 8d | 0d |
| A4230 |  | Relleno propio sin compactar | 14d | 2025-08-11 | 2025-08-24 | A4250 SS+5d, A4420, A4220 | 44d | 38d |

| ID | WBS | Activity | Duration | Start | Finish | Predecessors | Total float | Free float |
| --- | --- | --- | --- | --- | --- | --- | --- | --- |
|  | 3 | **ENROCADO DE PROTECCIÓN** |  | 2025-07-02 | 2025-09-03 |  |  |  |
| A2050 |  | Colocación de roca seleccionada, en uña antisocavante | 33d | 2025-07-02 | 2025-08-03 | A4190 | 6d | 0d |
| A2040 |  | Colocación de roca seleccionada, en cara húmeda de talud | 31d | 2025-08-04 | 2025-09-03 | A2050, A4250 SS | 6d | 0d |
|  | 1 | **SISTEMA DE CONFINAMIENTO CON GEOCELDAS** |  | 2025-08-02 | 2025-09-13 |  |  |  |
| A3830 |  | Suministro, habilitación y colocación de geotextil no tejido 200 g/m2 | 12d | 2025-08-02 | 2025-08-13 | A4250 SS, A4680 | 14d | 0d |
| A3850 |  | Suministro, habilitación y colocación de sistema de confinamiento geocelda h=100 mm | 19d | 2025-08-07 | 2025-08-25 | A3830 SS+5d | 14d | 0d |
| A3840 |  | Suministro y colocación de concreto premezclado f'c=210 kg/cm2 para geocelda | 11d | 2025-09-03 | 2025-09-13 | A3850 SS+27d | 14d | 8d |
|  | 14 | **S3-DIPR-02MI - MARGEN IZQUIERDO** |  | 2025-09-04 | 2026-01-12 |  |  |  |
|  | 4 | **REMOCION DE ENROCADO DE DIQUES EN MAL ESTADO** |  | 2025-09-04 | 2025-09-06 |  |  |  |
| A5040 |  | Remoción de enrocado de cara húmeda de talud | 3d | 2025-09-04 | 2025-09-06 | A5050 SS | 6d | 0d |
| A5050 |  | Selección y acopio de roca removida | 2d | 2025-09-04 | 2025-09-05 | A2040 | 6d | 0d |
|  | 5 | **MOVIMIENTO DE TIERRAS PARA DIQUE LONGITUDINALES** |  | 2025-09-04 | 2025-12-20 |  |  |  |
|  | 1 | **EXCAVACIÓN** |  | 2025-09-04 | 2025-11-19 |  |  |  |
| A5090 |  | Desbroce y remoción de suelo vegetal con equipo | 10d | 2025-09-04 | 2025-09-13 | A5040 SS | 6d | 0d |
| A5180 |  | Excavación en material común saturado | 16d | 2025-09-06 | 2025-09-21 | A5090 SS+2d | 6d | 0d |
| A5100 |  | Excavación para conformación de uña antisocavante | 43d | 2025-09-22 | 2025-11-03 | A5180, A3850, A3840 | 6d | 0d |
| A5170 |  | Excavación en material común | 59d | 2025-09-22 | 2025-11-19 | A5100 SS | 6d | 0d |
|  | 2 | **RELLENO** |  | 2025-10-02 | 2025-12-20 |  |  |  |
| A5120 |  | Conformación y compactación de superficie para fundación con equipo pesado | 5d | 2025-10-02 | 2025-10-06 | A5170 SS+10d, A4230 | 6d | 0d |
| A5130 |  | Relleno compactado con equipo pesado | 55d | 2025-10-07 | 2025-11-30 | A5120 SS+5d, A4220, A4220 FF | 48d | 44d |
| A5150 |  | Perfilado de taludes de dique con equipo | 25d | 2025-10-07 | 2025-10-31 | A5120 SS+5d | 6d | 0d |
| A5110 |  | Excavación de zanja de anclaje para geotextil | 19d | 2025-10-17 | 2025-11-04 | A5150 SS+10d | 6d | 0d |
| A5160 |  | Suministro, habilitación y colocación de geotextil no tejido 400 g/m2 | 59d | 2025-10-23 | 2025-12-20 | A5110 SS+6d | 6d | 0d |
| A5140 |  | Relleno propio sin compactar | 31d | 2025-10-28 | 2025-11-27 | A5160 SS+5d, A4230, A4220 | 6d | 0d |

| ID | WBS | Activity | Duration | Start | Finish | Predecessors | Total float | Free float |
| --- | --- | --- | --- | --- | --- | --- | --- | --- |
|  | 3 | **ENROCADO DE PROTECCIÓN** |  | 2025-11-04 | 2026-01-02 |  |  |  |
| A5030 |  | Colocación de roca seleccionada, en uña antisocavante | 60d | 2025-11-04 | 2026-01-02 | A5100 | 27d | 0d |
| A5020 |  | Colocación de roca seleccionada, en cara húmeda de talud | 36d | 2025-11-28 | 2026-01-02 | A5170, A5160 SS, A5140 | 6d | 3d |
|  | 1 | **SISTEMA DE CONFINAMIENTO CON GEOCELDAS** |  | 2025-10-23 | 2026-01-12 |  |  |  |
| A5060 |  | Suministro, habilitación y colocación de geotextil no tejido 200 g/m2 | 2d | 2025-10-23 | 2025-10-24 | A5160 SS | 30d | 0d |
| A5080 |  | Suministro, habilitación y colocación de sistema de confinamiento geocelda h=100 mm | 63d | 2025-10-28 | 2025-12-29 | A5060 SS+5d | 30d | 0d |
| A5070 |  | Suministro y colocación de concreto premezclado f'c=210 kg/cm2 para geocelda | 50d | 2025-11-24 | 2026-01-12 | A5080 SS+27d, A3840 | 54d | 16d |
|  | 15 | **S3-DIPR-01MD - MARGEN DERECHO** |  | 2025-05-18 | 2025-09-12 |  |  |  |
|  | 4 | **REMOCION DE ENROCADO DE DIQUES EN MAL ESTADO** |  | 2025-05-18 | 2025-05-21 |  |  |  |
| A5210 |  | Remoción de enrocado de cara húmeda de talud | 4d | 2025-05-18 | 2025-05-21 | A5220 SS | 0d |  |
| A5220 |  | Selección y acopio de roca removida | 3d | 2025-05-18 | 2025-05-20 | A4910 | 0d |  |
|  | 5 | **MOVIMIENTO DE TIERRAS PARA DIQUE LONGITUDINALES** |  | 2025-05-18 | 2025-08-18 |  |  |  |
|  | 1 | **EXCAVACIÓN** |  | 2025-05-18 | 2025-08-04 |  |  |  |
| A5260 |  | Desbroce y remoción de suelo vegetal con equipo | 18d | 2025-05-18 | 2025-06-04 | A5210 SS | 0d |  |
| A5350 |  | Excavación en material común saturado | 18d | 2025-05-20 | 2025-06-06 | A5260 SS+2d | 0d |  |
| A5270 |  | Excavación para conformación de uña antisocavante | 19d | 2025-06-07 | 2025-06-25 | A5350 | 0d |  |
| A5340 |  | Excavación en material común | 40d | 2025-06-26 | 2025-08-04 | A5270 | 11d | 0d |
|  | 2 | **RELLENO** |  | 2025-07-06 | 2025-08-18 |  |  |  |
| A5290 |  | Conformación y compactación de superficie para fundación con equipo pesado | 1d | 2025-07-06 | 2025-07-06 | A5340 SS+10d | 11d | 0d |
| A5300 |  | Relleno compactado con equipo pesado | 32d | 2025-07-11 | 2025-08-11 | A5290 SS+5d | 11d |  |
| A5320 |  | Perfilado de taludes de dique con equipo | 17d | 2025-07-11 | 2025-07-27 | A5290 SS+5d | 11d | 0d |
| A5280 |  | Excavación de zanja de anclaje para geotextil | 4d | 2025-07-21 | 2025-07-24 | A5320 SS+10d | 54d | 0d |
| A5330 |  | Suministro, habilitación y colocación de geotextil no tejido 400 g/m2 | 8d | 2025-07-27 | 2025-08-03 | A5280 SS+6d | 54d | 0d |
| A5310 |  | Relleno propio sin compactar | 18d | 2025-08-01 | 2025-08-18 | A5330 SS+5d, A4990 | 60d | 9d |

| ID | WBS | Activity | Duration | Start | Finish | Predecessors | Total float | Free float |
| --- | --- | --- | --- | --- | --- | --- | --- | --- |
|  | 3 | **ENROCADO DE PROTECCIÓN** |  | 2025-06-26 | 2025-08-21 |  |  |  |
| A5200 |  | Colocación de roca seleccionada, en uña antisocavante | 26d | 2025-06-26 | 2025-07-21 | A5270 | 0d |  |
| A5190 |  | Colocación de roca seleccionada, en cara húmeda de talud | 31d | 2025-07-22 | 2025-08-21 | A5200, A5320 SS, A5300 SS | 0d |  |
|  | 1 | **SISTEMA DE CONFINAMIENTO CON GEOCELDAS** |  | 2025-07-27 | 2025-09-12 |  |  |  |
| A5230 |  | Suministro, habilitación y colocación de geotextil no tejido 200 g/m2 | 16d | 2025-07-27 | 2025-08-11 | A5330 SS, A4870 | 54d | 0d |
| A5250 |  | Suministro, habilitación y colocación de sistema de confinamiento geocelda h=100 mm | 18d | 2025-08-01 | 2025-08-18 | A5230 SS+5d | 54d | 0d |
| A5240 |  | Suministro y colocación de concreto premezclado f'c=210 kg/cm2 para geocelda | 16d | 2025-08-28 | 2025-09-12 | A5250 SS+27d, A4870, A5310 | 54d | 51d |
|  | 16 | **S3-DIPR-02MD - MARGEN DERECHO** |  | 2025-08-22 | 2025-12-03 |  |  |  |
|  | 4 | **REMOCION DE ENROCADO DE DIQUES EN MAL ESTADO** |  | 2025-08-22 | 2025-09-02 |  |  |  |
| A5380 |  | Remoción de enrocado de cara húmeda de talud | 12d | 2025-08-22 | 2025-09-02 | A5390 SS | 0d |  |
| A5390 |  | Selección y acopio de roca removida | 6d | 2025-08-22 | 2025-08-27 | A5190 | 0d |  |
|  | 5 | **MOVIMIENTO DE TIERRAS PARA DIQUE LONGITUDINALES** |  | 2025-08-22 | 2025-11-19 |  |  |  |
|  | 1 | **EXCAVACIÓN** |  | 2025-08-22 | 2025-10-17 |  |  |  |
| A5430 |  | Desbroce y remoción de suelo vegetal con equipo | 10d | 2025-08-22 | 2025-08-31 | A5380 SS | 0d |  |
| A5520 |  | Excavación en material común saturado | 8d | 2025-08-24 | 2025-08-31 | A5430 SS+2d | 0d |  |
| A5440 |  | Excavación para conformación de uña antisocavante | 33d | 2025-09-01 | 2025-10-03 | A5520 | 0d |  |
| A5510 |  | Excavación en material común | 47d | 2025-09-01 | 2025-10-17 | A5440 SS | 0d |  |
|  | 2 | **RELLENO** |  | 2025-09-11 | 2025-11-19 |  |  |  |
| A5460 |  | Conformación y compactación de superficie para fundación con equipo pesado | 2d | 2025-09-11 | 2025-09-12 | A5510 SS+10d, A5300 | 3d | 0d |
| A5470 |  | Relleno compactado con equipo pesado | 39d | 2025-09-16 | 2025-10-24 | A5460 SS+5d | 32d |  |
| A5490 |  | Perfilado de taludes de dique con equipo | 24d | 2025-09-16 | 2025-10-09 | A5460 SS+5d | 3d | 0d |
| A5450 |  | Excavación de zanja de anclaje para geotextil | 8d | 2025-09-26 | 2025-10-03 | A5490 SS+10d | 3d | 0d |
| A5500 |  | Suministro, habilitación y colocación de geotextil no tejido 400 g/m2 | 25d | 2025-10-02 | 2025-10-26 | A5450 SS+6d | 3d | 0d |
| A5480 |  | Relleno propio sin compactar | 44d | 2025-10-07 | 2025-11-19 | A5500 SS+5d, A5310 | 11d |  |

| ID | WBS | Activity | Duration | Start | Finish | Predecessors | Total float | Free float |
| --- | --- | --- | --- | --- | --- | --- | --- | --- |
|  | 3 | **ENROCADO DE PROTECCIÓN** |  | 2025-10-04 | 2025-11-26 |  |  |  |
| A5370 |  | Colocación de roca seleccionada, en uña antisocavante | 46d | 2025-10-04 | 2025-11-18 | A5440 | 46d | 40d |
| A5360 |  | Colocación de roca seleccionada, en cara húmeda de talud | 40d | 2025-10-18 | 2025-11-26 | A5510, A5480 SS, A5470 SS | 0d |  |
|  | 1 | **SISTEMA DE CONFINAMIENTO CON GEOCELDAS** |  | 2025-10-02 | 2025-12-03 |  |  |  |
| A5400 |  | Suministro, habilitación y colocación de geotextil no tejido 200 g/m2 | 31d | 2025-10-02 | 2025-11-01 | A5500 SS | 3d | 0d |
| A5420 |  | Suministro, habilitación y colocación de sistema de confinamiento geocelda h=100 mm | 35d | 2025-10-07 | 2025-11-10 | A5400 SS+5d | 3d | 0d |
| A5410 |  | Suministro y colocación de concreto premezclado f'c=210 kg/cm2 para geocelda | 31d | 2025-11-03 | 2025-12-03 | A5420 SS+27d, A5230, A5240 | 3d |  |
|  | 17 | **S3-DIPR-03MD - MARGEN DERECHO** |  | 2025-11-27 | 2026-03-25 |  |  |  |
|  | 4 | **REMOCION DE ENROCADO DE DIQUES EN MAL ESTADO** |  | 2025-11-27 | 2025-12-02 |  |  |  |
| A5550 |  | Remoción de enrocado de cara húmeda de talud | 6d | 2025-11-27 | 2025-12-02 | A5560 SS | 0d |  |
| A5560 |  | Selección y acopio de roca removida | 3d | 2025-11-27 | 2025-11-29 | A5360 | 0d |  |
|  | 5 | **MOVIMIENTO DE TIERRAS PARA DIQUE LONGITUDINALES** |  | 2025-11-27 | 2026-02-16 |  |  |  |
|  | 1 | **EXCAVACIÓN** |  | 2025-11-27 | 2026-01-31 |  |  |  |
| A5600 |  | Desbroce y remoción de suelo vegetal con equipo | 8d | 2025-11-27 | 2025-12-04 | A5550 SS | 0d |  |
| A5690 |  | Excavación en material común saturado | 8d | 2025-11-29 | 2025-12-06 | A5600 SS+2d | 0d |  |
| A5610 |  | Excavación para conformación de uña antisocavante | 22d | 2025-12-07 | 2025-12-28 | A5690, A5410 | 0d |  |
| A5680 |  | Excavación en material común | 34d | 2025-12-29 | 2026-01-31 | A5610, A5370 | 6d | 0d |
|  | 2 | **RELLENO** |  | 2026-01-08 | 2026-02-16 |  |  |  |
| A5630 |  | Conformación y compactación de superficie para fundación con equipo pesado | 1d | 2026-01-08 | 2026-01-08 | A5680 SS+10d | 6d | 0d |
| A5640 |  | Relleno compactado con equipo pesado | 28d | 2026-01-13 | 2026-02-09 | A5630 SS+5d, A5470 | 6d | 0d |
| A5660 |  | Perfilado de taludes de dique con equipo | 20d | 2026-01-13 | 2026-02-01 | A5630 SS+5d | 38d | 0d |
| A5620 |  | Excavación de zanja de anclaje para geotextil | 9d | 2026-01-23 | 2026-01-31 | A5660 SS+10d | 38d | 0d |
| A5670 |  | Suministro, habilitación y colocación de geotextil no tejido 400 g/m2 | 2d | 2026-01-29 | 2026-01-30 | A5620 SS+6d | 38d | 0d |
| A5650 |  | Relleno propio sin compactar | 14d | 2026-02-03 | 2026-02-16 | A5670 SS+5d, A5480 | 74d | 33d |

| ID | WBS | Activity | Duration | Start | Finish | Predecessors | Total float | Free float |
| --- | --- | --- | --- | --- | --- | --- | --- | --- |
|  | 3 | **ENROCADO DE PROTECCIÓN** |  | 2025-12-29 | 2026-01-30 |  |  |  |
| A5540 |  | Colocación de roca seleccionada, en uña antisocavante | 30d | 2025-12-29 | 2026-01-27 | A5610 | 0d |  |
| A5530 |  | Colocación de roca seleccionada, en cara húmeda de talud | 3d | 2026-01-28 | 2026-01-30 | A5540 | 0d |  |
|  | 1 | **SISTEMA DE CONFINAMIENTO CON GEOCELDAS** |  | 2026-01-29 | 2026-03-25 |  |  |  |
| A5570 |  | Suministro, habilitación y colocación de geotextil no tejido 200 g/m2 | 36d | 2026-01-29 | 2026-03-05 | A5670 SS, A5070 | 38d | 0d |
| A5590 |  | Suministro, habilitación y colocación de sistema de confinamiento geocelda h=100 mm | 30d | 2026-02-03 | 2026-03-04 | A5570 SS+5d | 38d | 0d |
| A5580 |  | Suministro y colocación de concreto premezclado f'c=210 kg/cm2 para geocelda | 24d | 2026-03-02 | 2026-03-25 | A5590 SS+27d, A5410, A5670 | 38d | 33d |
|  | 4 | **SECTOR 4** |  | 2026-01-06 | 2026-03-25 |  |  |  |
|  | 2 | **S4-DIPR-02MI - MARGEN IZQUIERDO** |  | 2026-01-06 | 2026-02-12 |  |  |  |
|  | 1 | **MOVIMIENTO DE TIERRAS PARA DIQUE LONGITUDINALES** |  | 2026-01-06 | 2026-01-30 |  |  |  |
|  | 1 | **EXCAVACIÓN** |  | 2026-01-06 | 2026-01-25 |  |  |  |
| A3980 |  | Desbroce y remoción de suelo vegetal con equipo | 3d | 2026-01-06 | 2026-01-08 | A5020, A6030 SS | 3d | 0d |
| A3990 |  | Excavación en material común | 9d | 2026-01-09 | 2026-01-17 | A3980 | 3d | 0d |
| A4000 |  | Excavación para conformación de uña antisocavante | 6d | 2026-01-20 | 2026-01-25 | A3990 FS+2d | 3d | 0d |
|  | 2 | **RELLENO** |  | 2026-01-14 | 2026-01-30 |  |  |  |
| A4020 |  | Conformación y compactación de superficie para fundación con equipo pesado | 3d | 2026-01-14 | 2026-01-16 | A3990 SS+5d, A4210, A5130 | 4d | 0d |
| A4030 |  | Relleno compactado con equipo pesado | 16d | 2026-01-15 | 2026-01-30 | A4020 SS+1d, A5130, A5130 FF | 4d | 0d |
| A4050 |  | Perfilado de taludes de dique con equipo | 5d | 2026-01-17 | 2026-01-21 | A4030 SS+2d | 4d | 1d |
| A4010 |  | Excavación de zanja de anclaje para geotextil | 0d | 2026-01-26 | 2026-01-26 | A4000 | 3d | 0d |
| A4040 |  | Relleno propio sin compactar | 4d | 2026-01-26 | 2026-01-29 | A1440 SS, A5140 | 9d | 6d |
| A4060 |  | Suministro, habilitación y colocación de geotextil no tejido 400 g/m2 | 0d | 2026-01-26 | 2026-01-26 | A4050 SS+8d, A5080, A4010 | 3d | 0d |
|  | 3 | **ENROCADO DE PROTECCIÓN** |  | 2026-01-26 | 2026-02-12 |  |  |  |
| A1440 |  | Colocación de roca seleccionada, en cara húmeda de talud | 10d | 2026-01-26 | 2026-02-04 | A4000, A4060 SS | 3d | 0d |
| A1450 |  | Colocación de roca seleccionada, en uña antisocavante | 8d | 2026-02-05 | 2026-02-12 | A1440, A4040 | 3d | 0d |

| ID | WBS | Activity | Duration | Start | Finish | Predecessors | Total float | Free float |
| --- | --- | --- | --- | --- | --- | --- | --- | --- |
|  | 18 | **S4-DPR-03MD - MARGEN DERECHO** |  | 2026-01-31 | 2026-03-25 |  |  |  |
|  | 1 | **MOVIMIENTO DE TIERRAS PARA DIQUE LONGITUDINALES** |  | 2026-01-31 | 2026-03-25 |  |  |  |
|  | 1 | **EXCAVACIÓN** |  | 2026-01-31 | 2026-02-19 |  |  |  |
| A5720 |  | Desbroce y remoción de suelo vegetal con equipo | 3d | 2026-01-31 | 2026-02-02 | A5530 | 0d |  |
| A5730 |  | Excavación en material común | 8d | 2026-02-03 | 2026-02-10 | A5720 | 0d |  |
| A5740 |  | Excavación para conformación de uña antisocavante | 7d | 2026-02-13 | 2026-02-19 | A5730 FS+2d | 0d |  |
|  | 2 | **RELLENO** |  | 2026-02-08 | 2026-03-25 |  |  |  |
| A5760 |  | Conformación y compactación de superficie para fundación con equipo pesado | 5d | 2026-02-08 | 2026-02-12 | A5730 SS+5d | 7d | 1d |
| A5770 |  | Relleno compactado con equipo pesado | 8d | 2026-02-10 | 2026-02-17 | A5760 SS+1d, A5640 | 6d | 0d |
| A5750 |  | Excavación de zanja de anclaje para geotextil | 7d | 2026-02-11 | 2026-02-17 | A5730 | 8d | 2d |
| A5790 |  | Perfilado de taludes de dique con equipo | 5d | 2026-02-12 | 2026-02-16 | A5770 SS+2d | 6d | 0d |
| A5800 |  | Suministro, habilitación y colocación de geotextil no tejido 400 g/m2 | 4d | 2026-02-20 | 2026-02-23 | A5790 SS+8d, A5750 | 6d |  |
| A5780 |  | Relleno propio sin compactar | 4d | 2026-03-22 | 2026-03-25 | A5700 SS+30d, A5650, A5770 | 41d |  |
|  | 3 | **ENROCADO DE PROTECCIÓN** |  | 2026-02-20 | 2026-03-10 |  |  |  |
| A5700 |  | Colocación de roca seleccionada, en cara húmeda de talud | 10d | 2026-02-20 | 2026-03-01 | A5740, A5790 SS | 0d |  |
| A5710 |  | Colocación de roca seleccionada, en uña antisocavante | 9d | 2026-03-02 | 2026-03-10 | A5700, A5800 | 0d |  |
|  | 2 | **SECTOR 5** |  | 2026-02-13 | 2026-05-09 |  |  |  |
|  | 5 | **S5-DIPR-02MI - MARGEN IZQUIERDO** |  | 2026-02-13 | 2026-05-02 |  |  |  |
|  | 4 | **DESCOLMATACIÓN DE CAUCE DE RÍO - SECTOR 5** |  | 2026-02-13 | 2026-03-14 |  |  |  |
| A2380 |  | Excavación en material común saturado | 30d | 2026-02-13 | 2026-03-14 | A1450, A6050 SS | 3d | 0d |
|  | 5 | **MOVIMIENTO DE TIERRAS PARA DIQUE LONGITUDINALES** |  | 2026-03-15 | 2026-05-02 |  |  |  |
|  | 1 | **EXCAVACIÓN** |  | 2026-03-15 | 2026-03-26 |  |  |  |
| A4270 |  | Desbroce y remoción de suelo vegetal con equipo | 2d | 2026-03-15 | 2026-03-16 | A2380 | 3d | 0d |
| A4280 |  | Excavación para conformación de uña antisocavante | 6d | 2026-03-15 | 2026-03-20 | A4270 SS | 3d | 0d |
| A4710 |  | Excavación en material común | 6d | 2026-03-21 | 2026-03-26 | A4280 | 3d | 0d |

| ID | WBS | Activity | Duration | Start | Finish | Predecessors | Total float | Free float |
| --- | --- | --- | --- | --- | --- | --- | --- | --- |
|  | 2 | **RELLENO** |  | 2026-03-21 | 2026-05-02 |  |  |  |
| A4300 |  | Conformación y compactación de superficie para fundación con equipo pesado | 3d | 2026-03-21 | 2026-03-23 | A4710 SS, A4050 | 35d | 0d |
| A4310 |  | Relleno compactado con equipo pesado | 14d | 2026-03-24 | 2026-04-06 | A4300 SS+3d, A4030 | 35d | 0d |
| A4330 |  | Perfilado de taludes de dique con equipo | 9d | 2026-03-27 | 2026-04-04 | A4310 SS+3d | 35d | 0d |
| A4320 |  | Relleno propio sin compactar | 3d | 2026-04-30 | 2026-05-02 | A2340 SS+34d, A4040, A5580 | 3d |  |
|  | 3 | **ENROCADO DE PROTECCIÓN** |  | 2026-03-27 | 2026-04-12 |  |  |  |
| A2340 |  | Colocación de roca seleccionada, en cara húmeda de talud | 9d | 2026-03-27 | 2026-04-04 | A4710 | 3d | 0d |
| A4720 |  | Colocación de roca seleccionada, en uña antisocavante | 8d | 2026-04-05 | 2026-04-12 | A2340 | 38d | 2d |
|  | 19 | **S5-DIPR-03MD - MARGEN DERECHO** |  | 2026-03-11 | 2026-05-09 |  |  |  |
|  | 4 | **DESCOLMATACIÓN DE CAUCE DE RÍO - SECTOR 5** |  | 2026-03-11 | 2026-03-18 |  |  |  |
| A5820 |  | Excavación en material común saturado | 8d | 2026-03-11 | 2026-03-18 | A5710 | 0d |  |
|  | 5 | **MOVIMIENTO DE TIERRAS PARA DIQUE LONGITUDINALES** |  | 2026-03-11 | 2026-05-09 |  |  |  |
|  | 1 | **EXCAVACIÓN** |  | 2026-03-11 | 2026-04-01 |  |  |  |
| A5830 |  | Desbroce y remoción de suelo vegetal con equipo | 2d | 2026-03-11 | 2026-03-12 | A5820 SS | 9d | 0d |
| A5840 |  | Excavación para conformación de uña antisocavante | 6d | 2026-03-11 | 2026-03-16 | A5830 SS | 9d | 0d |
| A5910 |  | Excavación en material común | 12d | 2026-03-21 | 2026-04-01 | A5820 FS+2d | 0d |  |
|  | 2 | **RELLENO** |  | 2026-03-17 | 2026-05-09 |  |  |  |
| A5850 |  | Excavación de zanja de anclaje para geotextil | 7d | 2026-03-17 | 2026-03-23 | A5840 | 9d |  |
| A5860 |  | Conformación y compactación de superficie para fundación con equipo pesado | 3d | 2026-03-21 | 2026-03-23 | A5910 SS | 46d | 0d |
| A5870 |  | Relleno compactado con equipo pesado | 21d | 2026-03-24 | 2026-04-13 | A5860 SS+3d | 46d | 12d |
| A5890 |  | Perfilado de taludes de dique con equipo | 11d | 2026-04-05 | 2026-04-15 | A5870 SS, A4330 | 35d | 0d |
| A5900 |  | Suministro, habilitación y colocación de geotextil no tejido 400 g/m2 | 5d | 2026-04-20 | 2026-04-24 | A5890 SS+15d, A5800, A5850 | 35d |  |
| A5880 |  | Relleno propio sin compactar | 4d | 2026-05-06 | 2026-05-09 | A5810 SS+34d, A5780, A4320 | 0d |  |
|  | 3 | **ENROCADO DE PROTECCIÓN** |  | 2026-04-02 | 2026-04-23 |  |  |  |
| A5810 |  | Colocación de roca seleccionada, en cara húmeda de talud | 13d | 2026-04-02 | 2026-04-14 | A5910, A5850 | 0d |  |
| A5920 |  | Colocación de roca seleccionada, en uña antisocavante | 9d | 2026-04-15 | 2026-04-23 | A5810, A4720 | 36d |  |

| ID | WBS | Activity | Duration | Start | Finish | Predecessors | Total float | Free float |
| --- | --- | --- | --- | --- | --- | --- | --- | --- |
|  | 9 | **ESTRUCTURA DE CAPTACIÓN LATERAL** |  | 2025-03-30 | 2025-10-07 |  |  |  |
|  | 1 | **MOVIMIENTO DE TIERRAS** |  | 2025-03-30 | 2025-10-07 |  |  |  |
| A3310 |  | Trazo y replanteo de interferencia | 28d | 2025-03-30 | 2025-04-26 | A1040 FS+100d | 49d | 0d |
| A3290 |  | Excavación en material común | 28d | 2025-07-16 | 2025-08-12 | A3420 SS+80d | 49d | 0d |
| A3300 |  | Relleno compactado con equipo pesado | 9d | 2025-09-29 | 2025-10-07 | A3320 SS | 120d | 70d |
| A3320 |  | Relleno compactado para estructuras | 2d | 2025-09-29 | 2025-09-30 | A3400 SS+45d | 49d | 0d |
| A3330 |  | Relleno propio sin compactar | 2d | 2025-09-29 | 2025-09-30 | A3320 SS | 49d | 0d |
| A3710 |  | Proceso y seleccion de material propio | 2d | 2025-10-01 | 2025-10-02 | A3330 | 49d | 0d |
|  | 2 | **OBRAS DE CONCRETO** |  | 2025-04-27 | 2025-09-07 |  |  |  |
| A3420 |  | Desvío provisional - canal de tierra para estructuras de interferencias | 4d | 2025-04-27 | 2025-04-30 | A3310 | 49d | 0d |
| A3340 |  | Concreto premezclado f´c=100 kg/cm2, e=0.10 m para solado | 13d | 2025-07-31 | 2025-08-12 | A3290 SS+15d | 49d | 0d |
| A3350 |  | Cama de arena,e=0.20m para proteccion de tuberia | 15d | 2025-07-31 | 2025-08-14 | A3340 SS | 170d | 0d |
| A3360 |  | Concreto ciclopeo f´c=175kg/cm2 + 30%PM | 2d | 2025-07-31 | 2025-08-01 | A3290 SS+15d | 179d | 19d |
| A3390 |  | Acero de refuerzo f'y=4200 kg/cm2 | 8d | 2025-07-31 | 2025-08-07 | A3340 SS | 49d | 0d |
| A3380 |  | Encofrado y desencofrado para estructuras | 12d | 2025-08-15 | 2025-08-26 | A3390 SS+15d | 49d | 0d |
| A3400 |  | Concreto estructural premezclado f´c=280 kg/cm2 | 4d | 2025-08-15 | 2025-08-18 | A3380 SS | 49d | 0d |
| A3430 |  | Colocación de roca seleccionada, en uña antisocavante | 2d | 2025-08-19 | 2025-08-20 | A3400 | 88d | 14d |
| A3370 |  | Mampostería de piedra de concreto 70%pm + 30% concreto f´c=175 kg/cm2 | 6d | 2025-08-21 | 2025-08-26 | A3400 FF+8d, A3360 | 160d | 78d |
| A3410 |  | Concreto estructural premezclado f´c=280 kg/cm2 en 2da fase | 1d | 2025-09-03 | 2025-09-03 | A3400 FS+15d | 74d | 0d |
| A3720 |  | Juntas de dilatacion y contraccion | 4d | 2025-09-04 | 2025-09-07 | A3430, A3410 | 74d | 6d |
|  | 3 | **INSTALACIONES HIDRÁULICAS** |  | 2025-07-31 | 2025-09-29 |  |  |  |
| A3450 |  | Suministro, habilitación e instalación de rejilla métalica de B=3.10 m x h=2.67 m | 1d | 2025-07-31 | 2025-07-31 | A3350 SS | 170d | 44d |
| A3440 |  | Suministro, habilitación e instalación de compuerta tipo ARMCO Modelo 10, Izaje CPE-2, B=1400 x h=1400mm | 1d | 2025-09-14 | 2025-09-14 | A3400 SS+30d, A3720 | 126d | 0d |
| A3460 |  | Impermeabilización de estructuras enterradas con pintura asfáltica | 14d | 2025-09-14 | 2025-09-27 | A3440 SS, A3450 | 126d | 0d |
| A3470 |  | Suministro, habilitación e instalación de baranda metálica de tubo Ø 2" F°G° h=0.90 m | 2d | 2025-09-28 | 2025-09-29 | A3440 SS, A3460 | 126d | 77d |

| ID | WBS | Activity | Duration | Start | Finish | Predecessors | Total float | Free float |
| --- | --- | --- | --- | --- | --- | --- | --- | --- |
|  | 10 | **ALCANTARILLA DE RETORNO** |  | 2025-04-27 | 2025-12-21 |  |  |  |
|  | 1 | **MOVIMIENTO DE TIERRAS** |  | 2025-04-27 | 2025-12-21 |  |  |  |
| A3500 |  | Trazo y replanteo de interferencia | 2d | 2025-04-27 | 2025-04-28 | A3310 | 191d | 0d |
| A3480 |  | Excavación en material común | 5d | 2025-10-03 | 2025-10-07 | A3610 SS+15d, A3720, A3710 | 49d | 0d |
| A3490 |  | Relleno compactado con equipo pesado | 2d | 2025-12-17 | 2025-12-18 | A3510 SS, A3300 | 50d | 0d |
| A3510 |  | Relleno compactado para estructuras | 5d | 2025-12-17 | 2025-12-21 | A3590 SS+45d | 50d | 0d |
| A3520 |  | Relleno propio sin compactar | 2d | 2025-12-19 | 2025-12-20 | A3510 SS, A3490 | 50d | 23d |
|  | 2 | **OBRAS DE CONCRETO** |  | 2025-04-29 | 2025-12-15 |  |  |  |
| A3610 |  | Desvío provisional - canal de tierra para estructuras de interferencias | 2d | 2025-04-29 | 2025-04-30 | A3500 | 191d | 142d |
| A3530 |  | Concreto premezclado f´c=100 kg/cm2, e=0.10 m para solado | 3d | 2025-10-18 | 2025-10-20 | A3480 SS+15d | 49d | 0d |
| A3540 |  | Cama de arena,e=0.20m para proteccion de tuberia | 2d | 2025-10-18 | 2025-10-19 | A3530 SS | 102d | 0d |
| A3550 |  | Concreto ciclopeo f´c=175kg/cm2 + 30%PM | 3d | 2025-10-18 | 2025-10-20 | A3480 SS+15d | 105d | 23d |
| A3580 |  | Acero de refuerzo f'y=4200 kg/cm2 | 5d | 2025-10-18 | 2025-10-22 | A3530 SS | 49d | 0d |
| A3570 |  | Encofrado y desencofrado para estructuras | 5d | 2025-11-02 | 2025-11-06 | A3580 SS+15d | 49d | 0d |
| A3590 |  | Concreto estructural premezclado f´c=280 kg/cm2 | 2d | 2025-11-02 | 2025-11-03 | A3570 SS | 49d | 0d |
| A3560 |  | Mampostería de piedra de concreto 70%pm + 30% concreto f´c=175 kg/cm2 | 6d | 2025-11-13 | 2025-11-18 | A3590 FF+15d, A3370, A3550 | 82d | 55d |
| A3600 |  | Concreto estructural premezclado f´c=280 kg/cm2 en 2da fase | 2d | 2025-12-04 | 2025-12-05 | A3590 FS+30d | 49d | 0d |
| A3620 |  | Colocación de roca seleccionada, en uña antisocavante | 2d | 2025-12-06 | 2025-12-07 | A3600 | 49d | 0d |
| A3730 |  | Suministro y colocación de enrocado con mortero (70% enrocado + 30% mortero f'c=175kg/cm2) | 6d | 2025-12-08 | 2025-12-13 | A3620 | 49d | 0d |
| A3740 |  | Junta delatacion y contraccion | 2d | 2025-12-14 | 2025-12-15 | A3730 | 49d | 0d |
|  | 3 | **INSTALACIONES HIDRÁULICAS** |  | 2025-10-18 | 2025-12-21 |  |  |  |
| A3640 |  | Tubería HDPE corrugado | 6d | 2025-10-18 | 2025-10-23 | A3540 SS | 102d | 53d |
| A3630 |  | Compuerta antiretorno tipo clapeta | 5d | 2025-12-16 | 2025-12-20 | A3590 SS+30d, A3640, A3740, A3470 | 49d | 0d |
| A3650 |  | Rejilla Metálica (04 und) | 2d | 2025-12-16 | 2025-12-17 | A3630 SS | 148d | 121d |
| A3660 |  | Suministro, habilitación e instalación de junta de estanquidad waterstop 6" | 2d | 2025-12-16 | 2025-12-17 | A3630 SS | 49d | 0d |
| A3750 |  | Impermeabilización de estructuras enterradas con pintura asfáltica | 4d | 2025-12-18 | 2025-12-21 | A3660 | 49d | 22d |

| ID | WBS | Activity | Duration | Start | Finish | Predecessors | Total float | Free float |
| --- | --- | --- | --- | --- | --- | --- | --- | --- |
|  | 11 | **RAMPAS DE ACCESO** |  | 2026-01-13 | 2026-05-02 |  |  |  |
|  | 1 | **MOVIMIENTO DE TIERRAS PARA RAMPAS DE ACCESO** |  | 2026-01-13 | 2026-04-07 |  |  |  |
| A3670 |  | Movimiento de Tierras | 85d | 2026-01-13 | 2026-04-07 | A5040, A5030 FS+10d, A3750, A3520, A3560 | 27d | 0d |
|  | 2 | **SISTEMA DE CONFINAMIENTO CON GEOCELDAS** |  | 2026-04-18 | 2026-04-25 |  |  |  |
| A3680 |  | Sistema de confinamiento con geoceldas | 8d | 2026-04-18 | 2026-04-25 | A3670 FS+10d, A4060, A3650 | 27d | 0d |
|  | 3 | **OBRAS DE CONCRETO** |  | 2026-04-28 | 2026-05-02 |  |  |  |
| A3690 |  | Obras de Concreto | 5d | 2026-04-28 | 2026-05-02 | A3680 SS+10d, A5070, A5580 | 27d |  |
|  | 12 | **PRUEBAS DE CONTROL DE CALIDAD** |  | 2024-12-30 | 2026-05-09 |  |  |  |
| A3700 |  | Pruebas de Control de Calidad | 496d | 2024-12-30 | 2026-05-09 | A1000, A1130 | 20d |  |
